# Vehicle_Integration_Test

Schedule from MS Project, 2003-12-01 to 2004-02-25.
MBARI

## Calendars

- Standard: Mon-Fri 08:00-12:00, 13:00-17:00; Sat-Sun off.

## Schedule

| ID | WBS | Task | Type | Duration | Start | Finish | Predecessors | Total slack | Free slack | Constraint |
| --- | --- | --- | --- | --- | --- | --- | --- | --- | --- | --- |
| 1 | 1 | **Tail Section** |  | 60d? | 2003-12-04 | 2004-02-25 |  | 0d |  |  |
| 2 | 1.1 | Fairing Order Placed | milestone | 1d | 2003-12-04 | 2003-12-04 |  | 0d |  | start no earlier than 2003-12-04 |
| 3 | 1.2 | Fairing Fabrication |  | 55d | 2003-12-05 | 2004-02-19 | 2 | 0d |  |  |
| 4 | 1.3 | Fairing Arrive MBARI | milestone | 1d | 2004-02-20 | 2004-02-20 | 3 | 0d |  | start no earlier than 2004-02-19 |
| 5 | 1.4 | Fairing Machining & Fitting |  | 3d | 2004-02-23 | 2004-02-25 | 4 | 0d |  |  |
| 6 | 1.5 | Foam Order Finalized |  | 1d | 2003-12-15 | 2003-12-15 |  | 29d | 0d | start no earlier than 2003-12-15 |
| 7 | 1.6 | Foam Fab & Test @ CRP |  | 20d | 2003-12-16 | 2004-01-12 | 6 | 29d | 0d | finish no earlier than 2004-01-09 |
| 8 | 1.7 | Foam Ship from CRP | milestone | 1d | 2004-01-13 | 2004-01-13 | 7 | 29d | 2d | start no earlier than 2004-01-09 |
| 9 | 1.8 | Foam Arrive MBARI | milestone | 1d | 2004-01-16 | 2004-01-16 | 8 | 27d | 0d | start no earlier than 2004-01-16 |
| 10 | 1.9 | Foam Testfit |  | 1d | 2004-01-19 | 2004-01-19 | 9 | 27d |  | start no earlier than 2003-12-17 |
| 11 | 1.10 | Spheres Arrive MBARI | milestone | 1d | 2003-12-23 | 2003-12-23 |  | 44d | 0d | start no earlier than 2003-12-23 |
| 12 | 1.11 | Penetrators Arrive MBARI | milestone | 1d | 2003-12-23 | 2003-12-23 |  | 46d |  | start no earlier than 2003-12-23 |
| 13 | 1.12 | Pour Base Mold |  | 2d | 2003-12-24 | 2003-12-25 | 11 | 44d |  |  |
| 14 | 1.13 | **MVC electronics** |  | 35d? | 2003-12-16 | 2004-02-02 |  | 17d |  |  |
| 15 | 1.13.1 | Positionic order placed | milestone | 0d | 2003-12-22 | 2003-12-22 |  | 48d |  | start no earlier than 2003-12-22 |
| 16 | 1.13.2 | Positronic order deliverd | milestone | 0d | 2004-01-05 | 2004-01-05 |  | 37d |  | finish no earlier than 2004-01-05 |
| 17 | 1.13.3 | Power board layout complete | milestone | 0d | 2003-12-24 | 2003-12-24 |  | 46d |  | start no earlier than 2003-12-24 |
| 18 | 1.13.4 | Power board arrive MBARI | milestone | 0d | 2004-01-07 | 2004-01-07 |  | 27d | 0d | start no earlier than 2004-01-07 |
| 19 | 1.13.5 | Power board Assem & Test |  | 7d | 2004-01-07 | 2004-01-15 | 18 | 27d | 0d |  |
| 20 | 1.13.6 | Integrate into sphere |  | 1d? | 2004-01-16 | 2004-01-16 | 19 | 27d | 0d |  |
| 21 | 1.13.7 | Design mounting plates |  | 7d? | 2003-12-16 | 2003-12-24 |  | 45d |  | finish no earlier than 2003-12-24 |
| 22 | 1.13.8 | order sheet stock | milestone | 0d | 2003-12-23 | 2003-12-23 |  | 47d |  | start no earlier than 2003-12-23 |
| 23 | 1.13.9 | fabricate mounting plates |  | 3d? | 2003-12-29 | 2003-12-31 |  | 35d | 0d | finish no earlier than 2003-12-31 |
| 24 | 1.13.10 | mount sphere internals |  | 1d? | 2004-01-01 | 2004-01-01 | 23 | 35d | 0d |  |
| 25 | 1.13.11 | cable sphere internals |  | 3d | 2004-01-02 | 2004-01-06 | 24 | 35d | 8d |  |
| 26 | 1.13.12 | power in sphere internals |  | 1d? | 2004-02-02 | 2004-02-02 | 25, 20 | 17d |  | finish no earlier than 2004-02-02 |

| ID | WBS | Task | Type | Duration | Start | Finish | Predecessors | Total slack | Free slack | Constraint |
| --- | --- | --- | --- | --- | --- | --- | --- | --- | --- | --- |
| 28 | 2 | **Mid Section** |  | 18d? | 2003-12-22 | 2004-01-14 |  | 30d |  |  |
| 29 | 2.1 | **Lower Frame** |  | 18d? | 2003-12-22 | 2004-01-14 |  | 30d |  |  |
| 30 | 2.1.1 | Assemble Lower Frame |  | 2d | 2003-12-22 | 2003-12-23 |  | 42d | 0d | finish no earlier than 2003-12-23 |
| 31 | 2.1.2 | mount transducers & proj. |  | 1d? | 2003-12-24 | 2003-12-24 | 30 | 42d | 2d |  |
| 32 | 2.1.3 | Test Route SS & SBP Cabling |  | 3d | 2003-12-29 | 2003-12-31 | 31 | 40d |  | start no earlier than 2003-12-29 |
| 33 | 2.1.4 | Main Housing arrive from Reson | milestone | 0d | 2003-12-30 | 2003-12-30 |  | 39d | 0d | start no earlier than 2003-12-30 |
| 34 | 2.1.5 | Main Housing Electrical Checkout |  | 3d | 2003-12-30 | 2004-01-01 | 33 | 39d |  |  |
| 35 | 2.1.6 | Test fit Main Housing |  | 4d | 2004-01-05 | 2004-01-08 |  | 30d | 0d | finish no earlier than 2004-01-08 |
| 36 | 2.1.7 | Test fit SS & SBP Cabling |  | 1d | 2004-01-09 | 2004-01-09 | 35 | 30d | 0d |  |
| 37 | 2.1.8 | Midbody Electrical Tests |  | 3d | 2004-01-12 | 2004-01-14 | 36 | 30d | 0d |  |
| 38 | 2.1.9 | Midbody Electrically Operational | milestone | 0d | 2004-01-14 | 2004-01-14 | 37 | 30d |  |  |
| 39 | 2.1.10 | Fabricate Tabs |  | 2d | 2003-12-23 | 2003-12-24 |  | 44d | 0d | start no earlier than 2003-12-23 |
| 40 | 2.1.11 | Install Tabs | milestone | 0d | 2003-12-24 | 2003-12-24 | 39 | 44d | 12d |  |
| 41 | 2.2 | **Upper Frame** |  | 15d? | 2003-12-22 | 2004-01-09 |  | 33d |  |  |
| 42 | 2.2.1 | Order Castle Nut Components | milestone | 0d | 2003-12-23 | 2003-12-23 |  | 44d | 6d | finish no earlier than 2003-12-23 |
| 43 | 2.2.2 | Design Lifting Beam |  | 6d? | 2003-12-22 | 2003-12-29 |  | 33d | 0d | finish no earlier than 2003-12-29 |
| 44 | 2.2.3 | Design Foam Mods |  | 6d? | 2003-12-22 | 2003-12-29 |  | 40d | 0d | finish no earlier than 2003-12-29 |
| 45 | 2.2.4 | Order Beam Material | milestone | 0d | 2003-12-24 | 2003-12-24 |  | 46d |  | start no earlier than 2003-12-24 |
| 46 | 2.2.5 | Modify Foampack |  | 2d | 2003-12-30 | 2003-12-31 | 44 | 40d |  |  |
| 47 | 2.2.6 | Fabricate Lifting Beam |  | 8d | 2003-12-31 | 2004-01-09 | 43 | 32d | 0d | finish no earlier than 2004-01-09 |
| 48 | 2.2.7 | machine top fairing for beam |  | 1d? | 2003-12-30 | 2003-12-30 | 43 | 40d | 8d |  |
| 49 | 2.3 | Test fit upper & lower frame w/o lifting beam & tabs |  | 1d? | 2004-01-09 | 2004-01-09 | 35, 42 | 32d | 0d | start no earlier than 2003-12-31 |
| 50 | 2.4 | Adjust upper & lower foam packs |  | 1d? | 2004-01-12 | 2004-01-12 | 49 | 32d |  |  |
| 51 | 2.5 | Test fit midbody w/ tabs |  | 1d? | 2004-01-12 | 2004-01-12 | 40, 47, 48 | 32d |  |  |
| 53 | 3 | Software |  | 1d? | 2003-12-01 | 2003-12-01 |  | 62d |  |  |
